# AB-06 - met gipsmontagewanden

Schedule from MS Project, 2003-01-12 to 2003-03-02, status date 2003-01-08.
BAM Nelissen Van Egteren

## Calendars

- ALLEEN WERKDAGEN: Mon-Fri 08:30-12:30, 13:00-17:00; Sat-Sun off. Exceptions (off unless hours are given): 2003-01-11 to 2003-01-12 08:30-12:30, 13:00-17:00, 2003-01-18 to 2003-01-19 08:30-12:30, 13:00-17:00, 2003-01-25 to 2003-01-26 08:30-12:30, 13:00-17:00, 2003-02-01 to 2003-02-02 08:30-12:30, 13:00-17:00, 2003-02-08 to 2003-02-09 08:30-12:30, 13:00-17:00, 2003-02-15 to 2003-02-16 08:30-12:30, 13:00-17:00, 2003-02-22 to 2003-02-23 08:30-12:30, 13:00-17:00, 2003-03-01 to 2003-03-02 08:30-12:30, 13:00-17:00.

## Schedule

| ID | WBS | Task | Type | Duration | Start | Finish | Predecessors | Total slack |
| --- | --- | --- | --- | --- | --- | --- | --- | --- |
| 1 | 1 | **AFBOUWFASE** |  | 50d | 2003-01-12 | 2003-03-02 |  | 0d |
| 2 | 1.1 | **inbouwfase** |  | 20d | 2003-01-12 | 2003-01-31 |  | 0d |
| 3 | 1.1.1 | plafondleidingen vooraf | milestone | 0d | 2003-01-12 | 2003-01-12 |  | 50d |
| 4 | 1.1.2 | cementdekvloer aanbrengen |  | 4d | 2003-01-12 | 2003-01-15 |  | 0d |
| 5 | 1.1.3 | GM-wand frame monteren |  | 5d | 2003-01-16 | 2003-01-20 | 4SS+4d | 0d |
| 6 | 1.1.4 | GM-wand 1e beplating aanbr. |  | 5d | 2003-01-19 | 2003-01-23 | 5SS+3d | 0d |
| 7 | 1.1.5 | GM-wand leidingen in spouw |  | 5d | 2003-01-21 | 2003-01-25 | 6SS+2d | 0d |
| 8 | 1.1.6 | GM-wand sluitwand aanbr. |  | 5d | 2003-01-23 | 2003-01-27 | 7SS+2d | 0d |
| 9 | 1.1.7 | plafond randlat+regelwerk |  | 5d | 2003-01-25 | 2003-01-29 | 8SS+2d | 0d |
| 10 | 1.1.8 | plafond roosters+armaturen |  | 5d | 2003-01-27 | 2003-01-31 | 9SS+2d | 30d |
| 11 | 1.2 | **afwerkingsfase** |  | 20d | 2003-01-28 | 2003-02-16 |  | 0d |
| 12 | 1.2.1 | GM-wand behangklaar maken |  | 5d | 2003-01-28 | 2003-02-01 | 9SS+3d | 0d |
| 13 | 1.2.2 | GM-wand wandafwerking |  | 5d | 2003-01-31 | 2003-02-04 | 12SS+3d | 0d |
| 14 | 1.2.3 | plafondplaten inleggen |  | 5d | 2003-02-03 | 2003-02-07 | 13SS+3d | 0d |
| 15 | 1.2.4 | binnenwanden afwerken |  | 5d | 2003-02-06 | 2003-02-10 | 14SS+3d | 0d |
| 16 | 1.2.5 | harde vloerbedekking |  | 5d | 2003-02-09 | 2003-02-13 | 15SS+3d | 0d |
| 17 | 1.2.6 | zachte vloerbedekking |  | 5d | 2003-02-12 | 2003-02-16 | 16SS+3d | 0d |
| 18 | 1.3 | **uitrustingsfase** |  | 11d | 2003-02-14 | 2003-02-24 |  | 0d |
| 19 | 1.3.1 | binnendeuren afhangen |  | 5d | 2003-02-14 | 2003-02-18 | 17SS+2d | 0d |
| 20 | 1.3.2 | bouwkundige afmontage |  | 5d | 2003-02-16 | 2003-02-20 | 19SS+2d | 0d |
| 21 | 1.3.3 | electra afmontage |  | 5d | 2003-02-18 | 2003-02-22 | 20SS+2d | 0d |
| 22 | 1.3.4 | werktuigkundige afmontage |  | 5d | 2003-02-20 | 2003-02-24 | 21SS+2d | 0d |
| 23 | 1.3.5 | hang+sluitwerk afmonteren |  | 3d | 2003-02-21 | 2003-02-23 | 22SS+1d | 0d |
| 24 | 1.4 | **opleveringsfase** |  | 8d | 2003-02-23 | 2003-03-02 |  | 0d |
| 25 | 1.4.1 | vooropnemen afbouw |  | 2d | 2003-02-23 | 2003-02-24 | 23SS+2d | 0d |
| 26 | 1.4.2 | herstelwerkzaamheden |  | 5d | 2003-02-26 | 2003-03-02 | 25SS+3d | 0d |
| 27 | 1.4.3 | opleveren bouwlaag | milestone | 0d | 2003-03-02 | 2003-03-02 | 26SS+5d | 0d |
